# ShutdownMaiJuni2015

Schedule from MS Project, 2015-04-20 to 2015-12-09, A marks actual dates.
DESY

## Calendars

- Standard: Mon-Fri 08:00-12:00, 13:00-17:00; Sat-Sun off. Exceptions (off unless hours are given): 2015-05-14, 2015-05-25.

## Resources

| Resource |
| --- |
| MEA |
| BINP |
| MHF-p |
| MDI |
| MVS |
| LLRF |
| MPS |
| D3 |
| MHF-sl |
| MKK |
| IT |
| Uppsala |
| FS-LA |
| MKS |
| MKS/BINP |
| LLRF/MEA |
| INR |
| BAU |
| MKK-2 |
| MDI-FF |
| Wille_IMD |
| MEA-1 |
| MEA-2 |
| MSK |
| ??? MEA-1 |
| MCS-2 |
| TÜV |

## Schedule

| ID | WBS | Task | Duration | Start | Finish | Predecessors | Total slack | Free slack | Constraint |
| --- | --- | --- | --- | --- | --- | --- | --- | --- | --- |
| 1 | 1 | **Modul Installation** | 45d | 2015-09-15 | 2015-11-16 |  | 17d |  |  |
| 2 | 1.1 | 3.9er aufstellen | 1d | 2015-09-15 | 2015-09-15 |  | 17d | 0d | start no earlier than 2015-09-15 |
| 3 | 1.2 | 3.9er justieren | 1d | 2015-09-16 | 2015-09-16 | 2 | 17d | 0d |  |
| 4 | 1.3 | Schweißen | 20d | 2015-09-17 | 2015-10-14 | 3 | 17d | 0d | start no earlier than 2015-09-17 |
| 5 | 1.4 | LT - Vorbereitung | 1d | 2015-10-14 | 2015-10-14 | 4FS-1d | 17d | 0d |  |
| 6 | 1.5 | LT MC x 13 | 5d | 2015-10-15 | 2015-10-21 | 5 | 17d | 0d |  |
| 7 | 1.6 | Balgülsen u. BLA thermal connect | 3d | 2015-10-22 | 2015-10-26 | 6SS+5d | 17d | 0d |  |
| 8 | 1.7 | Schilde | 6d | 2015-10-26 | 2015-11-02 | 7SS+2d | 17d | 0d |  |
| 9 | 1.8 | Schiebemuffen schließen | 8d | 2015-10-27 | 2015-11-05 | 8SS+1d | 17d | 0d |  |
| 10 | 1.9 | Hohlleitermontage | 3w | 2015-10-21 | 2015-11-10 | 9FS-12d | 21d |  |  |
| 11 | 1.10 | Isoliervakuum: Pumpstandsinstallation (WP08) | 2d | 2015-11-04 | 2015-11-05 | 9FS-2d | 17d | 0d |  |
| 12 | 1.11 | Globaler HeLecktest des Isolationsvakuum (WP08) | 7d | 2015-11-06 | 2015-11-16 | 11 | 17d | 0d |  |
| 13 | 1.12 | kalte Magnete anschließen | 1w | 2015-09-17 | 2015-09-23 | 3 | 55d |  |  |
| 14 | 1.13 | Verkabelung fertigstellen (LLRF, MDI) | 4w | 2015-09-17 | 2015-10-14 | 3 | 40d |  |  |
| 15 | 1.14 | Verkabelung fertigstellen (MVS, MHF-sl,Kryo) | 4w | 2015-09-17 | 2015-10-14 | 3 | 25d | 0d |  |
| 16 | 1.15 | Verkabelung testen | 1w | 2015-10-15 | 2015-10-21 | 15 | 25d | 0d |  |
| 17 | 1.16 | Elektronik testen | 1w | 2015-10-22 | 2015-10-28 | 16 | 25d | 6d |  |
| 18 | 1.17 | Sensorik/Interlocks in Betrieb nehmen | 1w | 2015-11-06 | 2015-11-12 | 12SS, 17 | 19d |  |  |
| 19 | 2 | **3.9GHz HF-Station** | 24d | 2015-09-07 | 2015-10-08 |  | 44d |  |  |
| 20 | 2.1 | Aufstellung/Anschluss Modulator UG3 | 1w | 2015-09-07 | 2015-09-11 |  | 53d | 0d | start no earlier than 2015-09-07 |
| 21 | 2.2 | Inbetriebnahme Mod. Mit Load | 2w | 2015-09-14 | 2015-09-25 | 20 | 53d |  |  |
| 22 | 2.3 | Aufbau Trafo+Load UG7 | 4w | 2015-09-11 | 2015-10-08 |  | 44d |  | start no earlier than 2015-09-11 |
| 23 | 3 | **Diagnose Racks** | 8d | 2015-09-04 | 2015-09-15 |  | 61d |  |  |
| 24 | 3.1 | Kühlung in Betrieb nehmen | 3d | 2015-09-04 | 2015-09-08 |  | 63d | 2d | start no earlier than 2015-09-04 |
| 25 | 3.2 | M-TCS in Betrieb nehmen | 3d | 2015-09-11 | 2015-09-15 | 24 | 61d |  | start no earlier than 2015-09-11 |

| ID | WBS | Task | Duration | Start | Finish | Predecessors | Complete | Remaining | Total slack | Free slack | Constraint | Resources | Work | Actual work |
| --- | --- | --- | --- | --- | --- | --- | --- | --- | --- | --- | --- | --- | --- | --- |
| 26 | 4 | **warmes Vakuum** | 2d | 2015-04-20 | 2015-04-21 |  |  |  | 164d |  |  |  | 32h |  |
| 27 | 4.1 | Tausch Beamshutter | 2d | 2015-04-20 | 2015-04-21 |  |  |  | 164d | 0d |  | MVS | 16h |  |
| 28 | 4.2 | Beamline zum XSE | 2d | 2015-04-20 | 2015-04-21 | 27SS |  |  | 164d |  |  | MVS | 16h |  |
| 29 | 5 | **LLRF** | 10d | 2015-09-28 | 2015-10-09 |  |  |  | 43d |  |  |  | 80h |  |
| 30 | 5.1 | Racks bestücken+Inbetriebnahme | 2w | 2015-09-28 | 2015-10-09 |  |  |  | 43d |  | start no earlier than 2015-09-28 | LLRF | 80h |  |
| 31 | 6 | **Diagnose** | 15d | 2015-09-14 | 2015-10-02 |  |  |  | 48d |  |  |  | 80h |  |
| 32 | 6.1 | BAM und EOD Elektronik Einbau + Test | 2w | 2015-09-14 | 2015-09-25 |  |  |  | 53d |  | start no earlier than 2015-09-14 |  |  |  |
| 33 | 6.2 | BPM Elektronik Einbau + Test | 1w | 2015-09-21 | 2015-09-25 |  |  |  | 53d |  | start no earlier than 2015-09-21 | MDI | 40h |  |
| 34 | 6.3 | Gun Kameras justieren | 1w | 2015-09-21 | 2015-09-25 |  |  |  | 48d | 0d | start no earlier than 2015-09-21 | MDI | 40h |  |
| 35 | 6.4 | OTR-Kameras in Betrieb nehmen | 1w | 2015-09-28 | 2015-10-02 | 34 |  |  | 48d |  |  |  |  |  |
| 36 | 7 | **Pers. Interlock** | 8.5d | 2015-09-10 | 2015-09-22 |  |  |  | 56.5d |  |  |  | 28h |  |
| 37 | 7.1 | PM-Sicherheitsmagnet fertigstellen | 2d | 2015-09-10 | 2015-09-11 |  |  |  | 56.5d | 0d | start no earlier than 2015-09-10 |  |  |  |
| 38 | 7.2 | Vortest | 4h | 2015-09-14 | 2015-09-14 | 37 |  |  | 56.5d | 0d |  | MPS | 4h |  |
| 39 | 7.3 | TÜV-Abnahme | 1d | 2015-09-21 | 2015-09-22 | 38FS+5d |  |  | 56.5d |  | start no earlier than 2015-07-06 | MPS; D3; TÜV | 24h |  |
| 40 | 8 | **Laserheater** | 13d | 2015-09-28 A | 2015-10-14 |  | 23% | 10d | 40d |  |  |  | 104h | 24h |
| 41 | 8.1 | optische Mechatronik install. | 6d | 2015-09-28 A | 2015-10-05 |  | 50% | 3d | 40d | 0d |  | Uppsala | 48h | 24h |
| 42 | 8.2 | optische Mechatronik testen | 2d | 2015-10-06 | 2015-10-07 | 41 |  |  | 40d | 0d |  | Uppsala | 16h |  |
| 43 | 8.3 | Photodioden implementieren | 3d | 2015-10-08 | 2015-10-12 | 42 |  |  | 40d | 0d | start no earlier than 2015-06-24 | Uppsala | 24h |  |
| 44 | 8.4 | Delayline+Retroreflektor | 2d | 2015-10-13 | 2015-10-14 | 43 |  |  | 40d |  |  | Uppsala | 16h |  |
| 45 | 9 | **UV-Laser** | 4d | 2015-09-07 | 2015-09-10 |  |  |  | 64d |  |  |  | 32h |  |
| 46 | 9.1 | UV-Laser justieren | 4d | 2015-09-07 | 2015-09-10 |  |  |  | 64d |  | start no earlier than 2015-09-07 | FS-LA | 32h |  |
| 47 | 10 | **Installationen** | 42d | 2015-09-17 | 2015-11-13 |  |  |  | 18d |  |  |  | 136h |  |
| 48 | 10.1 | Aufbau Übergang | 2d | 2015-09-17 | 2015-09-18 |  |  |  | 58d |  | start no earlier than 2015-09-17 | MEA-1 | 16h |  |
| 49 | 10.2 | Abschirmung Diagnose Racks | 1w | 2015-10-26 | 2015-10-30 |  |  |  | 18d | 0d | start no earlier than 2015-10-26 | MEA-1 | 40h |  |
| 50 | 10.3 | Abschirmung Cryo Racks | 1w | 2015-11-02 | 2015-11-06 | 49 |  |  | 18d | 0d | start no earlier than 2015-10-26 | MEA-1 | 40h |  |
| 51 | 10.4 | Abschirmung Laser Heater | 1w | 2015-11-09 | 2015-11-13 | 50 |  |  | 18d |  |  | MEA-1 | 40h |  |

| ID | WBS | Task | Duration | Start | Finish | Predecessors | Total slack | Constraint |
| --- | --- | --- | --- | --- | --- | --- | --- | --- |
| 52 | 11 | **TDS** | 61d | 2015-09-16 | 2015-12-09 |  | 0d |  |
| 53 | 11.1 | Installation Modulator UG5 | 2w | 2015-09-16 | 2015-09-29 |  | 0d | start no earlier than 2015-09-16 |
| 54 | 11.2 | Modulator Test | 4w | 2015-09-30 | 2015-10-27 | 53 | 0d |  |
| 55 | 11.3 | Installation Personen Interlock | 1w | 2015-10-28 | 2015-11-03 | 54 | 0d |  |
| 56 | 11.4 | Einbau Klystron | 1w | 2015-11-04 | 2015-11-10 | 55 | 0d |  |
| 57 | 11.5 | TÜV Test | 1d | 2015-11-11 | 2015-11-11 | 56 | 0d |  |
| 58 | 11.6 | Inbetriebnahme | 4w | 2015-11-12 | 2015-12-09 | 57 | 0d |  |
| 59 | 12 | Undulatorinbetriebnahme | 1d | 2015-09-11 | 2015-09-11 |  | 63d | start no earlier than 2015-09-11 |
| 60 | 13 | Motorisierung Solenoiden | 3d | 2015-09-11 | 2015-09-15 |  | 61d | start no earlier than 2015-09-11 |
